# Name Access Control Module Project Schedule

Schedule from MS Project, 2007-01-09 to 2007-02-22, 4 hours a day.
Venaca

## Calendars

- Standard: Mon off; Tue 16:00-20:00; Wed off; Thu 16:00-20:00; Fri off; Sat-Sun 13:00-17:00.

## Resources

| Resource |
| --- |
| Matthew |
| Ben |
| Anthony |
| Dean |
| Rob |

## Schedule

| ID | WBS | Task | Duration | Start | Finish | Predecessors | Baseline start | Baseline finish | Baseline duration | Total slack | Free slack | Resources | Work |
| --- | --- | --- | --- | --- | --- | --- | --- | --- | --- | --- | --- | --- | --- |
| 1 | 1 | **Pre-Release** | 1d | 2007-01-09 | 2007-01-09 |  |  |  |  | 0d |  | Ben; Matthew; Rob | 28h |
| 2 | 1.1 | **SRS Document** | 1d | 2007-01-09 | 2007-01-09 |  |  |  |  | 0d |  | Ben; Matthew; Rob | 16h |
| 3 | 1.1.1 | Acceptance Testing Creation | 4h | 2007-01-09 | 2007-01-09 |  |  |  |  | 0d |  | Ben | 4h |
| 4 | 2 | **Release 1** | 10.5d | 2007-01-11 | 2007-01-28 | 1 | 2007-01-09 | 2007-01-25 | 9.5d | 0d |  | Anthony; Ben; Dean; Matthew; Rob | 486h |
| 5 | 2.1 | **Java Refreasher** | 1.5d | 2007-01-11 | 2007-01-13 |  |  |  |  | 5.5d |  |  | 8h |
| 6 | 2.1.1 | Java refresher for Matthew | 2h | 2007-01-11 | 2007-01-11 |  | 2007-01-09 | 2007-01-09 | 2h | 6.5d | 0d | Matthew | 2h |
| 7 | 2.1.2 | Java refresher for Ben | 6h | 2007-01-11 | 2007-01-13 |  | 2007-01-09 | 2007-01-11 | 6h | 7.75d | 0d | Ben | 6h |
| 8 | 2.2 | **Database** | 8d | 2007-01-11 | 2007-01-23 |  | 2007-01-09 | 2007-01-18 | 5.5d | 1.5d |  | Anthony | 64h |
| 9 | 2.2.1 | Setup server machine | 3h | 2007-01-11 | 2007-01-11 |  | 2007-01-09 | 2007-01-09 | 3h | 1.5d | 0d | Anthony | 3h |
| 10 | 2.2.2 | Install mySql on server machine | 3h | 2007-01-11 | 2007-01-13 | 9 | 2007-01-09 | 2007-01-11 | 3h | 1.5d | 0d | Anthony | 3h |
| 11 | 2.2.3 | Define the database schema | 14h | 2007-01-13 | 2007-01-18 | 10 | 2007-01-11 | 2007-01-13 | 4h | 1.5d | 0d | Anthony | 14h |
| 12 | 2.2.4 | Create the database creation script | 12h | 2007-01-20 | 2007-01-23 | 11 | 2007-01-13 | 2007-01-18 | 12h | 2.5d |  | Anthony | 12h |
| 13 | 2.3 | **Data Access Object** | 9d | 2007-01-11 | 2007-01-25 |  | 2007-01-09 | 2007-01-23 | 8.5d | 0d |  | Dean | 62h |
| 14 | 2.3.1 | Hibernate learning curve | 3h | 2007-01-11 | 2007-01-11 |  | 2007-01-09 | 2007-01-09 | 3h | 0d |  | Dean | 3h |
| 15 | 2.3.2 | Install Hibernate | 3h | 2007-01-11 | 2007-01-13 | 14 | 2007-01-09 | 2007-01-11 | 3h | 0d |  | Dean | 3h |
| 16 | 2.3.3 | Setup domain model | 4h | 2007-01-13 | 2007-01-14 | 15 | 2007-01-13 | 2007-01-14 | 4h | 0d |  | Dean | 4h |
| 17 | 2.3.4 | Define xml mappings for Hibernate | 8h | 2007-01-20 | 2007-01-21 | 16, 11 | 2007-01-14 | 2007-01-20 | 12h | 1.5d | 0d | Dean | 8h |
| 18 | 2.3.5 | Define interface to database through Hibernate | 8h | 2007-01-23 | 2007-01-25 | 17 | 2007-01-20 | 2007-01-23 | 8h | 1.5d |  | Dean | 8h |
| 19 | 2.4 | **Import MARC Records** | 5.25d | 2007-01-11 | 2007-01-20 |  | 2007-01-09 | 2007-01-20 | 6.75d | 4.75d |  | Matthew | 39h |
| 20 | 2.4.1 | XML Jave learning curve | 4h | 2007-01-11 | 2007-01-13 | 6 | 2007-01-09 | 2007-01-11 | 4h | 6.5d | 0d | Matthew | 4h |
| 21 | 2.4.2 | Define mapping of MARC bib xml to domain objects | 1h | 2007-01-13 | 2007-01-13 | 20 | 2007-01-11 | 2007-01-11 | 1h | 6.5d | 1.75d | Matthew | 1h |
| 22 | 2.4.3 | Create MARC bib record parser | 4h | 2007-01-14 | 2007-01-16 | 21, 16 | 2007-01-14 | 2007-01-16 | 4h | 4.75d | 0d | Matthew | 4h |
| 23 | 2.4.4 | Define mapping of MARC auth xml to domain objects | 1h | 2007-01-16 | 2007-01-16 | 22 | 2007-01-16 | 2007-01-16 | 1h | 4.75d | 0d | Matthew | 1h |
| 24 | 2.4.5 | Create MARC auth record parser | 4h | 2007-01-16 | 2007-01-18 | 23, 16 | 2007-01-16 | 2007-01-18 | 4h | 4.75d | 0d | Matthew | 4h |
| 25 | 2.4.6 | Create MARC name normalizer | 4h | 2007-01-18 | 2007-01-20 | 24, 16 | 2007-01-18 | 2007-01-20 | 4h | 4.75d |  | Matthew | 4h |

| ID | WBS | Task | Duration | Start | Finish | Predecessors | Baseline start | Baseline finish | Baseline duration | Total slack | Free slack | Resources | Work |
| --- | --- | --- | --- | --- | --- | --- | --- | --- | --- | --- | --- | --- | --- |
| 26 | 2.5 | **Authorize Name Matching** | 3d | 2007-01-13 | 2007-01-18 |  | 2007-01-09 | 2007-01-18 | 5.5d | 6d |  | Ben | 21h |
| 27 | 2.5.1 | Define rules for mapping MARC bib records to MARC auth records directly | 1h | 2007-01-13 | 2007-01-13 | 7 | 2007-01-11 | 2007-01-11 | 1h | 7.75d | 1.75d | Ben | 1h |
| 28 | 2.5.2 | Create the MatchStrategy for performing the direct mapping | 8h | 2007-01-14 | 2007-01-18 | 27, 16 | 2007-01-14 | 2007-01-18 | 8h | 6d |  | Ben | 8h |
| 29 | 2.6 | **Graphical User Interface - Core** | 6d | 2007-01-14 | 2007-01-25 |  | 2007-01-14 | 2007-01-25 | 6d | 0d |  | Rob | 48h |
| 30 | 2.6.1 | Import auth record | 2h | 2007-01-14 | 2007-01-14 | 16 | 2007-01-14 | 2007-01-14 | 2h | 0d |  | Rob | 2h |
| 31 | 2.6.2 | Import auth record folder | 2h | 2007-01-16 | 2007-01-16 | 30 | 2007-01-16 | 2007-01-16 | 2h | 0d |  | Rob | 2h |
| 32 | 2.6.3 | Import bib record | 2h | 2007-01-16 | 2007-01-16 | 31 | 2007-01-16 | 2007-01-16 | 2h | 0d |  | Rob | 2h |
| 33 | 2.6.4 | Import bib record folder | 2h | 2007-01-18 | 2007-01-18 | 32 | 2007-01-18 | 2007-01-18 | 2h | 0d |  | Rob | 2h |
| 34 | 2.6.5 | Match bib records in system to auth records in system | 2h | 2007-01-18 | 2007-01-18 | 33 | 2007-01-18 | 2007-01-18 | 2h | 0d |  | Rob | 2h |
| 35 | 2.6.6 | View all currently unconfirmed or unrejected matches | 14h | 2007-01-20 | 2007-01-25 | 34 | 2007-01-20 | 2007-01-25 | 14h | 0d |  | Rob | 14h |
| 36 | 2.7 | Systems Integeration | 6h | 2007-01-25 | 2007-01-27 | 29 |  |  |  | 0d |  | Matthew; Ben; Anthony; Dean; Rob | 30h |
| 37 | 2.8 | **Testing** | 0.5d | 2007-01-28 | 2007-01-28 | 29, 36 |  |  |  | 0d |  | Ben | 4h |
| 38 | 2.8.1 | Acceptance Tests | 2h | 2007-01-28 | 2007-01-28 |  |  |  |  | 0d |  | Ben | 2h |
| 39 | 3 | **Release 2** | 2d? | 2007-01-28 | 2007-02-01 | 4 |  |  |  | 0d |  | Anthony; Ben; Dean; Matthew; Rob | 60h |
| 40 | 3.1 | **Import Dublin Core Records** | 1d? | 2007-01-28 | 2007-01-30 |  |  |  |  | 0d |  | Matthew | 16h |
| 41 | 3.1.1 | Define Mapping of DC xml to domain objects | 1d? | 2007-01-28 | 2007-01-30 |  |  |  |  | 0d |  | Matthew | 4h |
| 42 | 3.1.2 | Create DC bib record parser | 1d? | 2007-01-28 | 2007-01-30 |  |  |  |  | 0d |  | Matthew | 4h |
| 43 | 3.1.3 | Create DC name normalizer | 1d? | 2007-01-28 | 2007-01-30 |  |  |  |  | 0d |  | Matthew | 4h |
| 44 | 3.2 | **Auxiliary Name Matching** | 1d? | 2007-01-28 | 2007-01-30 |  |  |  |  | 13d |  | Ben | 4h |
| 45 | 3.2.1 | Define rules for mapping bib records for auth records via alternative names | 1d? | 2007-01-28 | 2007-01-30 |  |  |  |  | 13d |  |  |  |
| 46 | 3.2.2 | Create the MatchStrategy for performing the direct mapping | 1d? | 2007-01-28 | 2007-01-30 |  |  |  |  | 13d |  |  |  |
| 47 | 3.3 | **Confirm/Reject posible match** | 2d? | 2007-01-28 | 2007-02-01 |  |  |  |  | 12d |  |  |  |
| 48 | 3.3.1 | Cofirm a possible match and update database | 1d? | 2007-01-28 | 2007-01-30 |  |  |  |  | 12d | 0d |  |  |
| 49 | 3.3.2 | Reject a possible match and update database | 1d? | 2007-01-28 | 2007-01-30 |  |  |  |  | 12d | 0d |  |  |
| 50 | 3.3.3 | Record who confirmed or rejected a possible match | 1d? | 2007-01-30 | 2007-02-01 | 49, 48 |  |  |  | 12d |  |  |  |

| ID | WBS | Task | Duration | Start | Finish | Predecessors | Total slack | Resources | Work |
| --- | --- | --- | --- | --- | --- | --- | --- | --- | --- |
| 51 | 3.4 | **Match duplicate incoming MARC records** | 1d? | 2007-01-28 | 2007-01-30 |  | 13d |  |  |
| 52 | 3.4.1 | Match incoming bib records | 1d? | 2007-01-28 | 2007-01-30 |  | 13d |  |  |
| 53 | 3.4.2 | Match incoming auth records | 1d? | 2007-01-28 | 2007-01-30 |  | 13d |  |  |
| 54 | 3.5 | **Filter/Sort all matches in the system** | 1d? | 2007-01-28 | 2007-01-30 |  | 13d |  |  |
| 55 | 3.5.1 | Filter matches on a specific field | 1d? | 2007-01-28 | 2007-01-30 |  | 13d |  |  |
| 56 | 3.5.2 | Sort matches on a specific field | 1d? | 2007-01-28 | 2007-01-30 |  | 13d |  |  |
| 57 | 4 | **Release 3** | 1d? | 2007-01-30 | 2007-02-01 | 40 | 0d | Anthony; Ben; Dean; Matthew; Rob | 20h |
| 58 | 4.1 | Creation of auth records based on unmatched bib records | 1d? | 2007-01-30 | 2007-02-01 |  | 0d |  |  |
| 59 | 4.2 | Match duplicate incoming DC bib records | 1d? | 2007-01-30 | 2007-02-01 |  | 12d |  |  |
| 60 | 4.3 | Merge incoming authrecords with existing auth records | 1d? | 2007-01-30 | 2007-02-01 |  | 12d |  |  |
| 62 | 5 | Release 4 | 3w | 2007-02-01 | 2007-02-22 | 58, 57 | 0d | Anthony; Ben; Dean; Matthew; Rob | 240h |
